# High Level Plan for SAPBiz 10-22-08 v4

How a schedule from MS Project changed from version to version. A marks actual dates.

## Version 1 (saved 2009-10-05)

| ID | WBS | Task | Duration | Start | Finish | Predecessors | Complete | Total float | Constraint |
| --- | --- | --- | --- | --- | --- | --- | --- | --- | --- |
| 1 | 1 | **2009 Support Pack Implementation Project** | 70d | 2008-09-15 | 2008-12-23 |  |  | 0d |  |
| 2 | 1.1 | **Project Prep & Planning** | 36.5d | 2008-09-15 | 2008-11-04 |  |  | 6.75d |  |
| 3 | 1.1.1 | **Appoint project team, define roles and responsibilities** | 1d | 2009-07-01 | 2009-07-01 |  |  | 0d |  |
| 4 |  | Appoint project manager | 1d? | 2009-08-10 A | 2009-08-10 A |  | 100% |  |  |
| 5 |  | Appoint core team | 1d? | 2009-08-10 A | 2009-08-10 A |  | 100% |  |  |
| 6 |  | Update business owner list with new / changed owners | 0.5d | 2009-08-10 A | 2009-08-10 A |  | 100% |  |  |
| 7 | 1.1.2 | **Define high level plan, milestones, deliverables** | 1d | 2010-01-15 | 2010-01-15 |  |  | 0d |  |
| 8 |  | Determine support packages availability date | 0.5d | 2009-08-10 A | 2009-08-10 A |  | 100% |  |  |
| 9 |  | Determine desired support package & enhancement package levels | 0.5d | 2009-08-10 A | 2009-08-10 A |  | 100% |  |  |
| 10 |  | Determine dates for production freeze | 0.5d | 2009-08-10 A | 2009-08-10 A |  | 100% |  |  |
| 11 | 1.1.3 | **Define environments, refresh schedule, support pack plan** | 1d | 2009-07-01 | 2009-07-01 |  |  | 0d |  |
| 12 |  | Identify clients fo Staging, and TST (DEV not refreshed) | 0.5d | 2009-08-10 A | 2009-08-10 A |  | 100% |  |  |
| 13 |  | Determine production snapshot dates for STG, TST | 0.5d | 2009-08-10 A | 2009-08-10 A |  | 100% |  |  |
| 14 |  | Determine dates for STG, TST refreshes | 0.5d | 2009-08-10 A | 2009-08-10 A |  | 100% |  |  |
| 15 |  | Plan datawarehouse extracts | 1d? | 2009-07-01 | 2009-07-01 |  |  | 0d |  |
| 16 | 1.1.4 | **Cleanup pending transports** | 0d | 2009-08-10 | 2009-08-10 |  |  | 63d |  |
| 17 |  | Create transport list | 1d | 2009-07-01 A | 2009-07-01 A |  | 100% |  |  |
| 18 |  | Determine status and plan for each | 5d | 2009-07-01 A | 2009-07-07 | 17 | 25% | 0d |  |
| 19 |  | Execute pending transport plan | 60d | 2009-07-01 A | 2009-09-22 |  | 25% | 0d |  |
| 20 |  | Upgrade Epi-use | 30d | 2009-07-01 | 2009-08-11 |  |  | 0d |  |
| 21 | 1.1.6 | **Test Planning** | 31.5d | 2008-09-22 | 2008-11-04 |  |  | 1.75d |  |
| 22 | 1.1.6.1 | **Update test script catalogs** | 13d | 2008-09-22 | 2008-10-08 |  |  | 1.75d |  |
| 23 |  | Define, document, communicate test case management procedure - templates, process, … | 1d? | 2009-07-01 | 2009-07-01 |  |  | 0d |  |
| 24 |  | Review transaction / report log for new items | 5d | 2008-09-22 | 2008-09-26 |  |  | 1.75d |  |
| 25 |  | Update test script catalog with new transactions / reports | 1d | 2008-09-29 | 2008-09-29 | 24 |  | 1.75d |  |
| 26 |  | Review test script catalog for missing / old test scripts | 2d | 2008-09-30 | 2008-10-01 | 25 |  | 1.75d |  |
| 27 |  | Create new / update old test scripts | 5d | 2008-10-02 | 2008-10-08 | 26 |  | 1.75d |  |
| 28 |  | Convert to new catalog | 1d? | 2009-07-01 | 2009-07-01 | 27 |  | 0d |  |
| 29 |  | Decide what to test in each functional area | 1d? | 2009-07-01 | 2009-07-01 | 28 |  | 0d |  |
| 30 |  | Convert test cases to new template | 1d? | 2009-07-01 | 2009-07-01 | 29 |  | 0d |  |
| 31 |  | Financial Team confirms completeness of test script catalog | 0d | 2008-10-08 | 2008-10-08 | 30 |  | 1.75d |  |
| 32 |  | Logistics Team confirms completeness of test script catalog | 0d | 2008-10-08 | 2008-10-08 | 27 |  | 52d | start no earlier than 2008-09-20 |
| 33 |  | EHS Team confirms completeness of test script catalog | 0d | 2008-10-08 | 2008-10-08 | 27 |  | 52d | start no earlier than 2008-09-20 |
| 34 |  | HR-Payroll Team confirms completeness of test script catalog | 0d | 2008-10-08 | 2008-10-08 | 27 |  | 33.5d | start no earlier than 2008-09-20 |
| 35 | 1.1.6.2 | **Unit Test Planning** | 1.5d | 2008-10-09 | 2008-10-10 |  |  | 33.5d |  |
| 36 |  | Determine transactions / reports to be tested | 1d | 2008-10-09 | 2008-10-09 | 34 |  | 33.5d |  |
| 37 |  | Update test script catalog | 0.5d | 2008-10-10 | 2008-10-10 | 36 |  | 33.5d |  |
| 38 | 1.1.6.3 | **Systems Integration Test Planning** | 17d | 2008-10-10 | 2008-11-04 |  |  | 33.5d |  |
| 39 |  | Define business scenarios | 2d | 2008-10-10 | 2008-10-14 | 37 |  | 33.5d |  |
| 40 |  | Document business scenarios | 10d | 2008-10-14 | 2008-10-28 | 39 |  | 33.5d |  |
| 41 |  | QA review of business scenarios | 3d | 2008-10-28 | 2008-10-31 | 40 |  | 33.5d |  |
| 42 |  | Update business scenarios as required | 1d | 2008-10-31 | 2008-11-03 | 41 |  | 33.5d |  |
| 43 |  | Financial Team confirms completeness of business scenarios | 0d | 2008-11-03 | 2008-11-03 | 42 |  | 34.5d |  |
| 44 |  | Logistics Team confirms completeness of business scenarios | 0d | 2008-11-03 | 2008-11-03 | 42 |  | 34.5d | start no earlier than 2008-09-20 |
| 45 |  | EHS Team confirms completeness of business scenarios | 0d | 2008-11-03 | 2008-11-03 | 42 |  | 34.5d | start no earlier than 2008-09-20 |
| 46 |  | HR-Payroll Team confirms completeness of business scenarios | 0d | 2008-11-03 | 2008-11-03 | 42 |  | 33.5d | start no earlier than 2008-09-20 |
| 47 |  | QA confirms completeness of business scenarios | 1d | 2008-11-03 | 2008-11-04 | 46 |  | 33.5d |  |
| 48 | 1.1.6.4 | **User Acceptance Test Planning** | 12d | 2008-10-13 | 2008-10-28 |  |  | -0.25d |  |
| 49 |  | Send test script catalog to business owners | 0.25d | 2009-08-10 | 2009-08-10 | 31, 6 |  | -1.25d | start no earlier than 2008-10-14 |
| 50 |  | Business owners select transactions and send back catalogs | 10d | 2008-10-13 | 2008-10-24 | 49 |  | -1.25d | finish no later than 2008-10-24 |
| 51 |  | Business owners define testers and send back list to Team leads | 10d | 2008-10-13 | 2008-10-24 | 49 |  | -1.25d | finish no later than 2008-10-24 |
| 52 |  | Business analysts update test script catalogs | 2d | 2008-10-27 | 2008-10-28 | 51 |  | 38d |  |
| 53 | 1.2 | **System Admin Preparation** | 2d | 2008-10-24 | 2008-10-27 |  |  | 39d |  |
| 54 |  | Produce Support Package Notes | 1d | 2009-08-10 | 2009-08-10 |  |  | 40d |  |
| 55 |  | Review and update action log from previous year | 2d | 2009-08-10 | 2009-08-11 |  |  | 39d |  |
| 56 |  | Upgrade Epi-use | 1d? | 2009-07-01 | 2009-07-01 |  |  | 0d |  |
| 57 |  | PS Snapshot for SF3 | 1d? | 2009-09-28 A | 2009-09-28 A |  | 100% |  | start no earlier than 2009-09-28 |
| 58 | 1.2.5 | **SFK Practice update (TBD)** | 7d | 2009-10-01 | 2009-10-09 |  |  | 0d |  |
| 59 |  | Test Install Basis Enhancement Pack 1 | 7d? | 2009-10-01 | 2009-10-10 |  |  | 0d |  |
| 60 |  | Test Install Enhancement Pack 4 | 7d? | 2009-10-01 | 2009-10-10 |  |  | 0d | finish no earlier than 2009-10-10 |
| 61 |  | Support packs available from SAP | 0d | 2009-10-15 | 2009-10-15 |  |  | 10d | start no earlier than 2009-10-15 |
| 62 | 1.4 | **SF3 System Refresh** | 5d | 2009-10-02 | 2009-10-08 |  |  | 44d |  |
| 63 |  | Refresh with 9/28/2009 PS1 Snapshot | 2d | 2009-10-02 | 2009-10-05 |  |  | 44d |  |
| 64 |  | Execute R3 Action Log | 0.5d | 2009-10-06 | 2009-10-06 |  |  | 44d |  |
| 65 |  | Scramble sensitive data | 2d | 2009-10-07 | 2009-10-08 |  |  | 44d | finish no earlier than 2009-10-08 |
| 66 |  | PS1 Snapshot for SH2 | 1d? | 2009-10-19 | 2009-10-19 |  |  | 0d | start no earlier than 2009-10-19 |
| 67 | 1.6 | **SFK Update (Evaluation)** | 4d | 2008-10-20 | 2008-10-23 | 61 |  | 10d |  |
| 68 |  | Apply SAP kernel update | 0.5d | 2009-10-19 | 2009-10-19 |  |  | 10d | start no earlier than 2009-10-19 |
| 69 |  | Upgrade Oracle db | 0.5d | 2009-10-20 | 2009-10-20 | 68 |  | 10d | start no earlier than 2009-10-20 |
| 70 |  | Install Basis Enhancement Pack 1 | 1d? | 2009-10-21 | 2009-10-21 | 69 |  | 0d | start no earlier than 2009-10-21 |

| ID | WBS | Task | Duration | Start | Finish | Predecessors | Total float | Constraint |
| --- | --- | --- | --- | --- | --- | --- | --- | --- |
| 71 |  | Install ECC Enhancement Pack 4 | 1d? | 2009-10-22 | 2009-10-22 | 70 | 0d | start no earlier than 2009-10-22 |
| 72 |  | Import support packages | 1d | 2009-10-23 | 2009-10-23 | 71, 61 | 10d | start no earlier than 2009-10-22 |
| 73 |  | Identify and resolve import issues | 0.5d | 2009-10-26 | 2009-10-26 | 72 | 10d | start no earlier than 2009-10-22 |
| 74 |  | Validate security infrastructure (SNC) | 0.5d | 2009-10-26 | 2009-10-26 | 73 | 10d | start no earlier than 2009-10-21 |
| 75 |  | Validate SAPGui interactions | 0.5d | 2009-10-27 | 2009-10-27 | 74 | 10d | start no earlier than 2009-10-21 |
| 76 |  | Validate basic SAP functions work | 0.5d | 2009-10-27 | 2009-10-27 | 75 | 10d | start no earlier than 2009-10-21 |
| 77 | 1.7 | **SF3 Update** | 3d | 2009-10-26 | 2009-10-28 | 62 | 0d |  |
| 78 |  | MIT mods, SPAU | 3d? | 2009-10-26 | 2009-10-28 |  | 0d | finish no earlier than 2009-10-28 |
| 79 | 1.8 | **SF2 Update (Development)** | 1d | 2008-10-31 | 2009-11-02 |  | 10d |  |
| 80 |  | Apply SAP kernel update | 0d | 2009-10-31 | 2009-10-31 |  | 10d | finish no earlier than 2009-10-31 |
| 81 |  | Upgrade Oracle db | 0d | 2009-10-31 | 2009-10-31 |  | 10d | finish no earlier than 2009-10-31 |
| 82 |  | Install Basis enhancement pack 1 | 0d? | 2009-11-01 | 2009-11-01 |  | 0d | finish no earlier than 2009-11-01 |
| 83 |  | Install ECC enhancement pack 4 | 1d? | 2009-11-02 | 2009-11-02 |  | 0d | start no earlier than 2009-11-01 |
| 84 |  | Import support packages | 1d | 2009-11-02 | 2009-11-02 |  | 10d | start no earlier than 2009-11-02 |
| 85 |  | Apply BSI Tax Factory Update | 0.25d | 2009-11-02 | 2009-11-02 |  | 10d | start no earlier than 2009-11-02 |
| 86 |  | Execute action log (add updates if necessary) | 0.5d | 2009-11-02 | 2009-11-02 |  | 10d | start no earlier than 2009-11-02 |
| 87 |  | Import transports from SF3 | 0.5d | 2009-11-02 | 2009-11-02 |  | 10d | start no earlier than 2009-11-02 |
| 88 | 1.9 | **Unit Test Execution in SF2** | 5d | 2009-11-02 | 2009-11-08 | 87 | 10d |  |
| 89 |  | Financial Unit Tests, Issue identification and retest | 5d | 2009-11-02 | 2009-11-08 | 87 | 29d | finish no earlier than 2009-11-08 |
| 90 |  | Logistics Unit Tests, Issue identification and retest | 5d | 2009-11-02 | 2009-11-08 | 87 | 29d | finish no earlier than 2009-11-08 |
| 91 |  | EHS Unit Tests, Issue identification and retest | 5d | 2009-11-02 | 2009-11-08 | 87 | 29d | finish no earlier than 2009-11-08 |
| 92 |  | HR-Payroll Unit Tests, Issue identification and retest | 5d | 2009-11-02 | 2009-11-08 | 87 | 10d | finish no earlier than 2009-11-08 |
| 93 |  | All functional teams ok environment and move to SIT | 0d | 2009-11-08 | 2009-11-08 |  | 10d | start no earlier than 2009-11-08 |
| 94 |  | SH2 System Refresh | 3d? | 2009-11-03 | 2009-11-05 |  | 0d | finish no earlier than 2009-11-05 |
| 95 |  | SH2 Update | 1d? | 2009-11-06 | 2009-11-08 |  | 0d | finish no earlier than 2009-11-08 |
| 96 | 1.12 | **Execute System Integration Tests in SH2** | 10d | 2009-11-09 | 2009-11-22 |  | 10d |  |
| 97 |  | Execute System Integration Tests | 6d | 2009-11-09 | 2009-11-16 | 126, 93 | 23d |  |
| 98 |  | Financial Close | 1d | 2009-11-17 | 2009-11-17 | 126, 93 | 23d |  |
| 99 |  | Issue Retesting | 3d | 2009-11-18 | 2009-11-20 | 126, 93 | 23d |  |
| 100 |  | System Integration Test sign-off | 1d | 2009-11-23 | 2009-11-23 | 126, 93 | 10d | finish no earlier than 2009-11-23 |
| 101 | 1.13 | **Execute User Acceptance Test (UAT) in SH2** | 13d | 2009-11-23 | 2009-12-09 |  | 8d |  |
| 102 |  | Execute UAT | 8d | 2009-11-24 | 2009-12-03 | 100 | 10d | start no earlier than 2009-11-23 |
| 103 |  | Financial Close | 2d | 2009-12-03 | 2009-12-04 |  | 10d |  |
| 104 |  | Issue retesting | 3d | 2009-12-07 | 2009-12-09 |  | 10d |  |
| 105 |  | UAT sign off | 1d | 2009-12-10 | 2009-12-10 |  | 7.75d | start no earlier than 2009-12-10 |
| 106 | 1.14 | **Cutover weekend & Controlled Start** | 0.25d | 2009-12-11 | 2009-12-13 | 105 | 7.75d |  |
| 107 |  | System message put out on SAP | 0.25d | 2009-12-11 | 2009-12-11 |  | 7.75d |  |
| 108 |  | System message put out on SAPWeb pages | 0.25d | 2009-12-11 | 2009-12-11 |  | 7.75d |  |
| 109 |  | Update production (detailed weekend cutover plan in a separate document) | 1d? | 2009-12-11 | 2009-12-13 |  | 0d |  |
| 110 |  | Production validation | 0d? | 2009-12-13 | 2009-12-13 |  | 0d |  |
| 111 |  | Go/No Go approval | 0d? | 2009-12-13 | 2009-12-13 |  | 0d |  |
| 112 |  | Updated production available | 1d? | 2009-12-14 | 2009-12-14 |  | 0d | start no earlier than 2009-12-14 |
| 113 |  | First Calendar 2010 Payroll | 0d | 2009-12-22 | 2009-12-22 |  | 0d | start no earlier than 2009-12-22 |
| 114 | 1.16 | **Following dates & sequence to be confirmed** | 1d | 2009-07-01 | 2009-07-01 |  | 0d |  |
| 115 |  | SF6 Refresh w/ 10/19/2009 snapshot (no data scrambling) | 3d | 2009-11-02 | 2009-11-04 |  | 13.25d | start no earlier than 2009-11-01 |
| 116 | 1.16.2 | **SF6 Update** | 4d | 2009-11-05 | 2009-11-10 |  | 13.25d |  |
| 117 |  | Import post snapshot production transports (delta from 10/20 to 10/30) | 0.5d | 2009-08-10 | 2009-08-10 |  | 13.25d |  |
| 118 |  | Apply kernel update | 0.5d | 2009-08-10 | 2009-08-10 |  | 13.25d |  |
| 119 |  | Upgrade Oracle db | 0.5d | 2009-08-10 | 2009-08-10 |  | 13.25d |  |
| 120 |  | Iinstall basis enhancement pack 1 | 1d? | 2009-07-01 | 2009-07-01 |  | 0d |  |
| 121 |  | Install ECC enhancement pack 4 | 1d? | 2009-07-01 | 2009-07-01 |  | 0d |  |
| 122 |  | Import support packages | 1d | 2009-08-10 | 2009-08-10 |  | 13.25d |  |
| 123 |  | Apply BSI Tax Factory Update | 0.25d | 2009-08-10 | 2009-08-10 |  | 13.25d |  |
| 124 |  | Import SF3 transports & post-update DEV transports (to be tested during SI & UAT) | 1d | 2009-08-10 | 2009-08-10 |  | 13.25d |  |
| 125 |  | Execute trial balance and compare with TB from 10/20 | 0.5d | 2009-08-10 | 2009-08-10 |  | 13.25d |  |
| 126 |  | Execute action log | 0.5d | 2009-08-10 | 2009-08-10 |  | 13.25d |  |
| 127 |  | Execute DWH extracts and comparison | 1d | 2009-08-10 | 2009-08-10 |  | 31.25d |  |
| 128 |  | SF7 Update | 1d? | 2009-12-01 | 2009-12-01 |  | 0d | start no earlier than 2009-12-01 |
| 129 |  | SH2 Status Change | 15d? | 2009-12-11 | 2009-12-31 |  | 0d | finish no earlier than 2009-12-31 |
| 130 |  | SH1 Status Change | 15d? | 2009-12-11 | 2009-12-31 |  | 0d | finish no earlier than 2009-12-31 |
| 131 |  | SF5 Status Change | 15d? | 2009-12-11 | 2009-12-31 |  | 0d | finish no earlier than 2009-12-31 |
| 132 |  | PS1 Snapshot for SF5 | 1d? | 2009-12-16 | 2009-12-16 |  | 0d | start no earlier than 2009-12-16 |
| 133 |  | SF5 System refresh & update | 4d? | 2010-01-04 | 2010-01-07 |  | 0d | finish no earlier than 2010-01-07 |
| 134 |  | PS1 Snapshot for SF8 | 1d? | 2009-12-16 | 2009-12-16 |  | 0d | start no earlier than 2009-12-16 |
| 135 |  | SF8 System Refresh & Update | 1d? | 2010-01-28 | 2010-01-28 |  | 0d | start no earlier than 2010-01-28 |

## Version 2 (saved 2009-10-05)

Last finish stays 2010-01-28.

Added:

| ID | Task | Duration | Start | Finish | Predecessors | Resources |
| --- | --- | --- | --- | --- | --- | --- |
| 67 | DW pull & store extracts | 1d | 2009-10-20 | 2009-10-20 | 66 | Elena |
| 78 | **Zuttreq updates** | 0.25d | 2009-10-23 | 2009-10-23 |  |  |
| 79 | Change target system in Zuttreq | 0.25d | 2009-10-23 | 2009-10-23 | 72 | Wai-Ming |
| 99 | DW pull & store extracts | 0.5d | 2009-11-09 | 2009-11-09 | 98 | Elena |
| 100 | Compare extracts | 0.5d | 2009-11-09 | 2009-11-09 | 99 | Elena |
| 119 | Freeze Ends | 3d | 2009-12-22 | 2009-12-24 | 118 |  |
| 142 | **Zuttreq updates** | 0.25d | 2010-01-08 | 2010-01-08 |  |  |
| 143 | Change target system in Zuttreq | 0.25d | 2010-01-08 | 2010-01-08 | 139 | Wai-Ming |

Changed:

| ID | Task | Start | Finish | Duration | Complete | Total float | Predecessors |
| --- | --- | --- | --- | --- | --- | --- | --- |
| 1 | **2009 Support Pack Implementation Project** | 2008-09-15 → 2008-10-13 A (+28d) | 2008-12-23 → 2010-01-28 (+401d) | 70d → 334d? | 0% → 7% |  |  |
| 2 | **Project Prep & Planning** | 2008-09-15 → 2008-10-13 A (+28d) | 2008-11-04 → 2009-09-22 (+322d) | 36.5d → 242d? | 0% → 14% | 6.75d → 92d |  |
| 3 | **Appoint project team, define roles and responsibilities** | 2009-07-01 → 2009-08-10 A (+40d) | 2009-07-01 → 2009-08-10 A (+40d) | 1d → 1d? | 0% → 100% | 0d → none |  |
| 7 | **Define high level plan, milestones, deliverables** | 2010-01-15 → 2009-08-10 A (-158d) | 2010-01-15 → 2009-08-10 A (-158d) | 1d → 0.5d | 0% → 100% | 0d → none |  |
| 11 | **Define environments, refresh schedule, support pack plan** | 2009-07-01 A | 2009-07-01 → 2009-08-10 (+40d) | 1d → 28.5d? | 0% → 60% | 0d → 123.5d |  |
| 16 | **Cleanup pending transports** | 2009-08-10 → 2009-07-01 A (-40d) | 2009-08-10 → 2009-09-22 (+43d) | 0d → 60d | 0% → 26% | 63d → 92d |  |
| 21 | **Test Planning** | 2008-09-22 → 2008-10-13 (+21d) | 2008-11-04 → 2009-08-13 (+282d) | 31.5d → 213.5d? |  | 1.75d → -16.25d |  |
| 22 | **Update test script catalogs** | 2008-09-22 → 2009-07-01 (+282d) | 2008-10-08 → 2009-07-22 (+287d) | 13d → 16d? |  | 1.75d → -198.25d |  |
| 24 | Review transaction / report log for new items | 2008-09-22 → 2009-07-01 (+282d) | 2008-09-26 → 2009-07-07 (+284d) |  |  | 1.75d → -198.25d |  |
| 25 | Update test script catalog with new transactions / reports | 2008-09-29 → 2009-07-08 (+282d) | 2008-09-29 → 2009-07-08 (+282d) |  |  | 1.75d → -198.25d |  |
| 26 | Review test script catalog for missing / old test scripts | 2008-09-30 → 2009-07-09 (+282d) | 2008-10-01 → 2009-07-10 (+282d) |  |  | 1.75d → -198.25d |  |
| 27 | Create new / update old test scripts | 2008-10-02 → 2009-07-13 (+284d) | 2008-10-08 → 2009-07-17 (+282d) |  |  | 1.75d → -198.25d |  |
| 28 | Convert to new catalog | 2009-07-01 → 2009-07-20 (+19d) | 2009-07-01 → 2009-07-20 (+19d) |  |  | 0d → -198.25d |  |
| 29 | Decide what to test in each functional area | 2009-07-01 → 2009-07-21 (+20d) | 2009-07-01 → 2009-07-21 (+20d) |  |  | 0d → -198.25d |  |
| 30 | Convert test cases to new template | 2009-07-01 → 2009-07-22 (+21d) | 2009-07-01 → 2009-07-22 (+21d) |  |  | 0d → -198.25d |  |
| 31 | Financial Team confirms completeness of test script catalog | 2008-10-08 → 2009-07-22 (+287d) | 2008-10-08 → 2009-07-22 (+287d) |  |  | 1.75d → -198.25d |  |
| 32 | Logistics Team confirms completeness of test script catalog | 2008-10-08 → 2009-07-17 (+282d) | 2008-10-08 → 2009-07-17 (+282d) |  |  | 52d → 139d |  |
| 33 | EHS Team confirms completeness of test script catalog | 2008-10-08 → 2009-07-17 (+282d) | 2008-10-08 → 2009-07-17 (+282d) |  |  | 52d → 139d |  |
| 34 | HR-Payroll Team confirms completeness of test script catalog | 2008-10-08 → 2009-07-17 (+282d) | 2008-10-08 → 2009-07-17 (+282d) |  |  | 33.5d → 120.5d |  |
| 35 | **Unit Test Planning** | 2008-10-09 → 2009-07-20 (+284d) | 2008-10-10 → 2009-07-21 (+284d) |  |  | 33.5d → 120.5d |  |
| 36 | Determine transactions / reports to be tested | 2008-10-09 → 2009-07-20 (+284d) | 2008-10-09 → 2009-07-20 (+284d) |  |  | 33.5d → 120.5d |  |
| 37 | Update test script catalog | 2008-10-10 → 2009-07-21 (+284d) | 2008-10-10 → 2009-07-21 (+284d) |  |  | 33.5d → 120.5d |  |
| 38 | **Systems Integration Test Planning** | 2008-10-10 → 2009-07-21 (+284d) | 2008-11-04 → 2009-08-13 (+282d) |  |  | 33.5d → 120.5d |  |
| 39 | Define business scenarios | 2008-10-10 → 2009-07-21 (+284d) | 2008-10-14 → 2009-07-23 (+282d) |  |  | 33.5d → 120.5d |  |
| 40 | Document business scenarios | 2008-10-14 → 2009-07-23 (+282d) | 2008-10-28 → 2009-08-06 (+282d) |  |  | 33.5d → 120.5d |  |
| 41 | QA review of business scenarios | 2008-10-28 → 2009-08-06 (+282d) | 2008-10-31 → 2009-08-11 (+284d) |  |  | 33.5d → 120.5d |  |
| 42 | Update business scenarios as required | 2008-10-31 → 2009-08-11 (+284d) | 2008-11-03 → 2009-08-12 (+282d) |  |  | 33.5d → 120.5d |  |
| 43 | Financial Team confirms completeness of business scenarios | 2008-11-03 → 2009-08-12 (+282d) | 2008-11-03 → 2009-08-12 (+282d) |  |  | 34.5d → 121.5d |  |
| 44 | Logistics Team confirms completeness of business scenarios | 2008-11-03 → 2009-08-12 (+282d) | 2008-11-03 → 2009-08-12 (+282d) |  |  | 34.5d → 121.5d |  |
| 45 | EHS Team confirms completeness of business scenarios | 2008-11-03 → 2009-08-12 (+282d) | 2008-11-03 → 2009-08-12 (+282d) |  |  | 34.5d → 121.5d |  |
| 46 | HR-Payroll Team confirms completeness of business scenarios | 2008-11-03 → 2009-08-12 (+282d) | 2008-11-03 → 2009-08-12 (+282d) |  |  | 33.5d → 120.5d |  |
| 47 | QA confirms completeness of business scenarios | 2008-11-03 → 2009-08-12 (+282d) | 2008-11-04 → 2009-08-13 (+282d) |  |  | 33.5d → 120.5d |  |
| 48 | **User Acceptance Test Planning** |  | 2008-10-28 → 2009-08-10 (+286d) | 12d → 210.75d |  |  |  |
| 53 | **System Admin Preparation** | 2008-10-24 → 2009-07-01 A (+250d) | 2008-10-27 → 2009-10-10 (+348d) | 2d → 73d? | 0% → 5% | 39d → 79d |  |
| 54 | Produce Support Package Notes | 2009-08-10 → 2009-07-01 (-40d) | 2009-08-10 → 2009-07-01 (-40d) |  |  | 40d → 151d |  |
| 55 | Review and update action log from previous year | 2009-08-10 → 2009-07-01 (-40d) | 2009-08-11 → 2009-07-02 (-40d) |  |  | 39d → 150d |  |
| 58 | **SFK Practice update (TBD)** | 2009-10-01 → 2009-07-01 (-92d) | 2009-10-09 → 2009-10-10 (+1d) | 7d → 73d? |  | 0d → 79d |  |
| 59 | Test Install Basis Enhancement Pack 1 | 2009-10-01 → 2009-07-01 (-92d) | 2009-10-10 → 2009-07-09 (-93d) |  |  | 0d → 145d |  |
| 62 | **SF3 System Refresh** | 2009-10-02 → 2009-07-01 (-93d) |  | 5d → 72d |  | 44d → 77d |  |
| 63 | Refresh with 9/28/2009 PS1 Snapshot | 2009-10-02 → 2009-07-01 (-93d) | 2009-10-05 → 2009-07-02 (-95d) |  |  | 44d → 147d |  |
| 64 | Execute R3 Action Log | 2009-10-06 → 2009-07-01 (-97d) | 2009-10-06 → 2009-07-01 (-97d) |  |  | 44d → 148.5d |  |
| 68 | **SFK Update (Evaluation)** | 2008-10-20 → 2009-10-19 (+364d) | 2008-10-23 → 2009-10-27 (+369d) | 4d → 7d? |  | 10d → 67d |  |
| 80 | **SF3 Update** |  |  | 3d → 3d? |  | 0d → 66d |  |
| 82 | **SF2 Update (Development)** | 2008-10-31 → 2009-10-31 (+365d) |  | 1d → 1d? |  | 10d → 58.5d |  |
| 91 | **Unit Test Execution in SF2** |  | 2009-11-08 → 2009-11-09 (+1d) |  |  | 10d → 58.5d |  |
| 92 | Financial Unit Tests, Issue identification and retest |  | 2009-11-08 → 2009-11-09 (+1d) |  |  | 29d → 58.5d |  |
| 93 | Logistics Unit Tests, Issue identification and retest |  | 2009-11-08 → 2009-11-09 (+1d) |  |  | 29d → 58.5d |  |
| 94 | EHS Unit Tests, Issue identification and retest |  | 2009-11-08 → 2009-11-09 (+1d) |  |  | 29d → 58.5d |  |
| 95 | HR-Payroll Unit Tests, Issue identification and retest |  | 2009-11-08 → 2009-11-09 (+1d) |  |  | 10d → 58.5d |  |
| 101 | **Execute System Integration Tests in SH2** | 2009-11-09 → 2009-11-10 (+1d) | 2009-11-22 → 2009-11-23 (+1d) |  |  | 10d → 48d |  |
| 102 | Execute System Integration Tests | 2009-11-09 → 2009-11-10 (+1d) | 2009-11-16 → 2009-11-17 (+1d) |  |  | 23d → 52d | 132, 96 → 132, 100 |
| 103 | Financial Close | 2009-11-17 → 2009-11-10 (-7d) | 2009-11-17 → 2009-11-10 (-7d) |  |  | 23d → 57d | 132, 96 → 132, 100 |
| 104 | Issue Retesting | 2009-11-18 → 2009-11-10 (-8d) | 2009-11-20 → 2009-11-12 (-8d) |  |  | 23d → 55d | 132, 96 → 132, 100 |
| 105 | System Integration Test sign-off |  |  |  |  | 10d → 40d | 132, 96 → 132, 100 |
| 106 | **Execute User Acceptance Test (UAT) in SH2** | 2009-11-23 → 2009-07-01 (-145d) | 2009-12-09 → 2009-12-10 (+1d) | 13d → 117d |  | 8d → 35d |  |
| 108 | Financial Close | 2009-12-03 → 2009-07-01 (-155d) | 2009-12-04 → 2009-07-02 (-155d) |  |  | 10d → 150d |  |
| 109 | Issue retesting | 2009-12-07 → 2009-07-01 (-159d) | 2009-12-09 → 2009-07-03 (-159d) |  |  | 10d → 149d |  |
| 111 | **Cutover weekend & Controlled Start** | 2009-12-11 → 2009-12-10 (-1d) | 2009-12-13 → 2009-12-14 (+1d) | 0.25d → 2d? |  | 7.75d → 33d |  |
| 114 | Update production (detailed weekend cutover plan in a separate document) |  | 2009-12-13 → 2009-12-11 (-2d) |  |  | 0d → 34d |  |
| 115 | Production validation | 2009-12-13 → 2009-12-10 (-3d) | 2009-12-13 → 2009-12-10 (-3d) |  |  | 0d → 35d |  |
| 116 | Go/No Go approval | 2009-12-13 → 2009-12-10 (-3d) | 2009-12-13 → 2009-12-10 (-3d) |  |  | 0d → 35d |  |
| 120 | **Following dates & sequence to be confirmed** |  | 2009-07-01 → 2010-01-28 (+211d) | 1d → 152d? |  |  |  |
| 122 | **SF6 Update** | 2009-11-05 → 2009-07-01 (-127d) | 2009-11-10 → 2009-07-01 (-132d) | 4d → 1d? |  | 13.25d → 142.5d |  |
| 123 | Import post snapshot production transports (delta from 10/20 to 10/30) | 2009-08-10 → 2009-07-01 (-40d) | 2009-08-10 → 2009-07-01 (-40d) |  |  | 13.25d → 151.5d |  |
| 124 | Apply kernel update | 2009-08-10 → 2009-07-01 (-40d) | 2009-08-10 → 2009-07-01 (-40d) |  |  | 13.25d → 151.5d |  |
| 125 | Upgrade Oracle db | 2009-08-10 → 2009-07-01 (-40d) | 2009-08-10 → 2009-07-01 (-40d) |  |  | 13.25d → 151.5d |  |
| 128 | Import support packages | 2009-08-10 → 2009-07-01 (-40d) | 2009-08-10 → 2009-07-01 (-40d) |  |  | 13.25d → 151d |  |
| 129 | Apply BSI Tax Factory Update | 2009-08-10 → 2009-07-01 (-40d) | 2009-08-10 → 2009-07-01 (-40d) |  |  | 13.25d → 151.75d |  |
| 130 | Import SF3 transports & post-update DEV transports (to be tested during SI & UAT) | 2009-08-10 → 2009-07-01 (-40d) | 2009-08-10 → 2009-07-01 (-40d) |  |  | 13.25d → 151d |  |
| 131 | Execute trial balance and compare with TB from 10/20 | 2009-08-10 → 2009-07-01 (-40d) | 2009-08-10 → 2009-07-01 (-40d) |  |  | 13.25d → 151.5d |  |

| ID | Task | Start | Finish | Total float |
| --- | --- | --- | --- | --- |
| 132 | Execute action log | 2009-08-10 → 2009-07-01 (-40d) | 2009-08-10 → 2009-07-01 (-40d) | 13.25d → 142.5d |
| 133 | Execute DWH extracts and comparison | 2009-08-10 → 2009-07-01 (-40d) | 2009-08-10 → 2009-07-01 (-40d) | 31.25d → 151d |

## Version 3 (saved 2009-10-07)

Last finish stays 2010-01-28.

Changed:

| ID | Task | Start | Finish | Duration | Total float | Other |
| --- | --- | --- | --- | --- | --- | --- |
| 53 | **System Admin Preparation** |  | 2009-10-10 → 2009-10-14 (+4d) | 73d? → 76d? | 79d → 76d |  |
| 58 | **SFK Practice update (TBD)** | 2009-07-01 → 2009-10-06 (+97d) | 2009-10-10 → 2009-10-14 (+4d) | 73d? → 7d | 79d → 76d |  |
| 59 | Test Install Basis Enhancement Pack 1 | 2009-07-01 → 2009-10-06 (+97d) | 2009-07-09 → 2009-10-14 (+97d) | 7d? → 7d | 145d → 76d | constraint none → start no earlier than 2009-10-06 |
| 60 | Test Install Enhancement Pack 4 | 2009-10-01 → 2009-10-06 (+5d) | 2009-10-10 → 2009-10-14 (+4d) | 7d? → 7d | 0d → 76d | constraint finish no earlier than 2009-10-10 → start no earlier than 2009-10-06 |

## Version 4 (saved 2009-10-13)

Last finish stays 2010-01-28. Complete tasks 11 → 13.

Added:

| ID | Task | Duration | Start | Finish | Predecessors | Constraint |
| --- | --- | --- | --- | --- | --- | --- |
| 76 | Change target system for transport layer | 1d? | 2009-10-23 | 2009-10-23 |  | start no earlier than 2009-10-23 |
| 79 | Apply SAP kernel update | 0.5d | 2009-10-22 | 2009-10-22 |  | start no earlier than 2009-10-22 |
| 80 | Upgrade Oracle db | 0.5d | 2009-10-23 | 2009-10-23 | 79 | start no earlier than 2009-10-23 |
| 81 | Install Support packages, Basis Enhancement Pack 1, ERP EH 4, + Additional packages req'd for HR | 3d? | 2009-10-26 | 2009-10-28 | 80 | finish no earlier than 2009-10-28 |
| 82 | Update BSI | 3d? | 2009-10-26 | 2009-10-28 |  | finish no earlier than 2009-10-28 |
| 84 | Check, decide, apply MIT mods or use enhancement framework | 2d? | 2009-10-30 | 2009-11-02 |  | finish no earlier than 2009-11-02 |
| 85 | SAP developer functionality validation | 1d? | 2009-10-29 | 2009-10-29 |  | start no earlier than 2009-10-29 |
| 86 | Apply updates for SAML authentication | 1d? | 2009-11-02 | 2009-11-02 | 83 | start no earlier than 2009-10-30 |
| 87 | Apply updates for SAP connect email functionality | 1d? | 2009-11-03 | 2009-11-03 | 83 | start no earlier than 2009-11-03 |
| 88 | Validate - external interfaces ITS, jco, mitid, fax. | 1d? | 2009-11-03 | 2009-11-03 |  | start no earlier than 2009-11-03 |
| 89 | Open enrollment transports to production | 1d? | 2009-10-29 | 2009-10-29 |  | start no earlier than 2009-10-29 |
| 94 | Apply updates for SAML authentication | 1d? | 2009-11-02 | 2009-11-02 |  | start no earlier than 2009-11-02 |
| 95 | Apply updates for SAP connect email functionality | 1d? | 2009-11-02 | 2009-11-02 |  | finish no earlier than 2009-11-02 |
| 106 | **SH2 Update** | 3d | 2009-11-04 | 2009-11-06 |  |  |
| 107 | Apply SAP kernel update | 1d | 2009-11-04 | 2009-11-04 |  | finish no earlier than 2009-11-04 |
| 108 | Upgrade Oracle db | 1d | 2009-11-04 | 2009-11-04 |  | finish no earlier than 2009-11-04 |
| 109 | Install Support packages, Basis Enhancement Pack 1, ERP EH 4, + Additional packages req'd for HR | 2d? | 2009-11-05 | 2009-11-06 |  | finish no earlier than 2009-11-06 |
| 110 | Apply BSI Tax Factory Update | 0.25d | 2009-11-05 | 2009-11-05 |  | start no earlier than 2009-11-05 |
| 111 | Apply updates for SAML authentication | 1d? | 2009-11-06 | 2009-11-06 |  | start no earlier than 2009-11-06 |
| 112 | Apply updates for SAP connect email functionality | 1d? | 2009-11-06 | 2009-11-06 |  | start no earlier than 2009-11-06 |
| 113 | Import transports from SF3 & SF2 | 0.5d | 2009-11-06 | 2009-11-06 |  | start no earlier than 2009-11-06 |
| 114 | Execute action log (add updates if necessary) | 0.5d | 2009-11-06 | 2009-11-06 |  | start no earlier than 2009-11-06 |

Removed: 72 Install ECC Enhancement Pack 4; 73 Import support packages; 74 Identify and resolve import issues; 86 Install ECC enhancement pack 4; 87 Import support packages; 98 SH2 Update; 99 DW pull & store extracts

Changed:

| ID | Task | Start | Finish | Duration | Complete | Total float | Predecessors | Other |
| --- | --- | --- | --- | --- | --- | --- | --- | --- |
| 58 | **SH3 Practice update (TBD)** |  |  |  |  |  |  | was named SFK Practice update (TBD) |
| 59 | Test Install Basis Enhancement Pack 1 | 2009-10-06 → 2009-10-08 (+2d) | 2009-10-14 → 2009-10-16 (+2d) |  |  |  |  | constraint start no earlier than 2009-10-06 → finish no earlier than 2009-10-16 |
| 60 | Test Install Enhancement Pack 4 | 2009-10-06 → 2009-10-08 (+2d) | 2009-10-14 → 2009-10-16 (+2d) |  |  |  |  | constraint start no earlier than 2009-10-06 → finish no earlier than 2009-10-16 |
| 63 | Refresh with 9/28/2009 PS1 Snapshot | 2009-07-01 A | 2009-07-02 A |  | 0% → 100% | 147d → none |  |  |
| 64 | Execute R3 Action Log | 2009-07-01 A | 2009-07-01 A |  | 0% → 100% | 148.5d → none |  |  |
| 70 | Upgrade Oracle db | 2009-10-20 → 2009-10-19 (-1d) | 2009-10-20 → 2009-10-19 (-1d) |  |  |  |  | constraint start no earlier than 2009-10-20 → start no earlier than 2009-10-19 |
| 71 | Install Support packages, Basis Enhancement Pack 1, ERP EH 4, + Additional packages req'd for HR | 2009-10-21 → 2009-10-20 (-1d) | 2009-10-21 → 2009-10-23 (+2d) | 1d? → 4d? |  |  |  | was named Install Basis Enhancement Pack 1; constraint start no earlier than 2009-10-21 → finish no earlier than 2009-10-23 |
| 72 | Validate security infrastructure (SNC) | 2009-10-26 → 2009-10-23 (-3d) | 2009-10-26 → 2009-10-24 (-2d) | 0.5d → 1d |  |  | Identify and resolve import issues → 71 | constraint start no earlier than 2009-10-21 → finish no earlier than 2009-10-24 |
| 73 | Validate SAPGui interactions | 2009-10-27 → 2009-10-23 (-4d) | 2009-10-27 → 2009-10-23 (-4d) |  |  |  | 72 → 71 | constraint start no earlier than 2009-10-21 → finish no earlier than 2009-10-23 |
| 74 | Validate basic SAP functions work | 2009-10-27 → 2009-10-23 (-4d) | 2009-10-27 → 2009-10-23 (-4d) | 0.5d → 1d |  |  | 73 → 71 | constraint start no earlier than 2009-10-21 → finish no earlier than 2009-10-23 |
| 77 | Change target system in Zuttreq |  |  |  |  |  | Install ECC Enhancement Pack 4 → none |  |
| 83 | SPAU, OSS notes | 2009-10-26 → 2009-10-29 (+3d) | 2009-10-28 → 2009-10-30 (+2d) | 3d? → 2d? |  |  |  | was named MIT mods, SPAU; constraint finish no earlier than 2009-10-28 → finish no earlier than 2009-10-30 |
| 91 | Apply SAP kernel update | 2009-10-31 → 2009-10-30 (-1d) | 2009-10-31 → 2009-10-30 (-1d) | 0d → 1d |  |  |  | constraint finish no earlier than 2009-10-31 → finish no earlier than 2009-10-30 |
| 92 | Upgrade Oracle db | 2009-10-31 → 2009-10-30 (-1d) | 2009-10-31 → 2009-10-30 (-1d) | 0d → 1d |  |  |  | constraint finish no earlier than 2009-10-31 → finish no earlier than 2009-10-30 |
| 93 | Install Support packages, Basis Enhancement Pack 1, ERP EH 4, + Additional packages req'd for HR | 2009-11-01 → 2009-10-30 (-2d) |  | 0d? → 1d? |  |  |  | was named Install Basis enhancement pack 1 |
| 97 | Apply BSI Tax Factory Update |  |  |  |  |  |  | constraint start no earlier than 2009-11-02 → start no earlier than 2009-10-31 |
| 99 | **Unit Test Execution in SF2** |  |  |  |  |  | 96 → 90 |  |
| 100 | Financial Unit Tests, Issue identification and retest | 2009-11-02 → 2009-11-03 (+1d) |  | 5d → 4.5d |  |  | 96 → none | constraint finish no earlier than 2009-11-08 → start no earlier than 2009-11-03 |
| 101 | Logistics Unit Tests, Issue identification and retest | 2009-11-02 → 2009-11-03 (+1d) |  | 5d → 4.5d |  |  | 96 → none | constraint finish no earlier than 2009-11-08 → start no earlier than 2009-11-03 |
| 102 | EHS Unit Tests, Issue identification and retest | 2009-11-02 → 2009-11-03 (+1d) |  | 5d → 4.5d |  |  | 96 → none | constraint finish no earlier than 2009-11-08 → start no earlier than 2009-11-03 |
| 103 | HR-Payroll Unit Tests, Issue identification and retest | 2009-11-02 → 2009-11-03 (+1d) |  | 5d → 4.5d |  |  | 96 → none | constraint finish no earlier than 2009-11-08 → start no earlier than 2009-11-03 |
| 105 | SH2 System Refresh | 2009-11-03 → 2009-10-26 (-8d) | 2009-11-05 → 2009-10-30 (-6d) | 3d? → 5d? |  |  |  | constraint finish no earlier than 2009-11-05 → finish no earlier than 2009-10-30 |
| 115 | Compare data warehouse extracts |  |  |  |  |  | DW pull & store extracts → none | was named Compare extracts |
| 121 | **Execute User Acceptance Test (UAT) in SH2** | 2009-07-01 → 2009-11-24 (+146d) | 2009-12-10 → 2009-12-09 (-1d) | 117d → 12d |  | 35d → 0d |  |  |
| 122 | Execute UAT |  | 2009-12-03 → 2009-12-04 (+1d) | 8d → 9d |  |  | 120 → none | constraint start no earlier than 2009-11-23 → finish no earlier than 2009-12-04 |
| 123 | Financial Close | 2009-07-01 → 2009-12-04 (+156d) | 2009-07-02 → 2009-12-04 (+155d) | 2d → 1d |  |  |  | constraint none → finish no earlier than 2009-12-04 |
| 124 | Issue retesting | 2009-07-01 → 2009-12-05 (+157d) | 2009-07-03 → 2009-12-09 (+159d) |  |  |  |  | constraint none → start no earlier than 2009-12-05 |
| 134 | Freeze Ends | 2009-12-22 → 2009-12-24 (+2d) |  | 3d → 1d |  |  |  | constraint none → finish no earlier than 2009-12-24 |

## Version 5 (saved 2009-10-20)

Last finish stays 2010-01-28.

Added:

| ID | Task | Duration | Start | Finish | Constraint |
| --- | --- | --- | --- | --- | --- |
| 90 | Netweaver/Adobe Document Server Update (Larch) | 2d? | 2009-10-29 | 2009-10-30 | finish no earlier than 2009-10-30 |
| 128 | Netweaver/Adobe Document Server Update (Snowbell) | 1d? | 2009-12-11 | 2009-12-11 |  |

Changed:

| ID | Task | Start | Finish | Duration | Complete | Total float |
| --- | --- | --- | --- | --- | --- | --- |
| 1 | **2009 Support Pack Implementation Project** |  |  |  | 7% → 8% |  |
| 53 | **System Admin Preparation** |  | 2009-10-14 → 2009-10-16 (+2d) | 76d? → 78d? |  | 76d → 74d |
| 58 | **SH3 Practice update (TBD)** | 2009-10-06 → 2009-10-08 (+2d) | 2009-10-14 → 2009-10-16 (+2d) |  |  | 76d → 74d |
| 62 | **SF3 System Refresh** | 2009-07-01 A |  |  | 0% → 56% | 77d → 76d |
| 68 | **SFK Update (Evaluation)** |  | 2009-10-27 → 2009-10-26 (-1d) | 7d? → 6d? |  | 67d → 68d |
| 72 | Validate security infrastructure (SNC) | 2009-10-23 → 2009-10-26 (+3d) | 2009-10-24 → 2009-10-26 (+2d) |  |  | 67d → 68d |
| 73 | Validate SAPGui interactions | 2009-10-23 → 2009-10-26 (+3d) | 2009-10-23 → 2009-10-26 (+3d) |  |  | 67d → 68.5d |
| 74 | Validate basic SAP functions work | 2009-10-23 → 2009-10-26 (+3d) | 2009-10-23 → 2009-10-26 (+3d) |  |  | 67d → 68d |
| 75 | **Zuttreq updates** | 2009-10-23 → 2009-07-01 (-114d) |  | 0.25d → 83d? |  | 69.75d → 69d |
| 77 | Change target system in Zuttreq | 2009-10-23 → 2009-07-01 (-114d) | 2009-10-23 → 2009-07-01 (-114d) |  |  | 69.75d → 151.75d |
| 78 | **SF3 Update** | 2009-10-26 → 2009-10-22 (-4d) | 2009-10-28 → 2009-11-03 (+6d) | 3d? → 9d? |  | 66d → 62d |
| 91 | **SF2 Update (Development)** | 2009-10-31 → 2009-10-30 (-1d) |  | 1d? → 2d? |  |  |
| 100 | **Unit Test Execution in SF2** | 2009-11-02 → 2009-11-03 (+1d) |  | 5d → 4.5d |  |  |
| 107 | **SH2 Update** |  |  | 3d → 3d? |  | 0d → 59d |
| 116 | Compare data warehouse extracts | 2009-11-09 → 2009-07-01 (-131d) | 2009-11-09 → 2009-07-01 (-131d) |  |  | 49d → 145.5d |
| 117 | **Execute System Integration Tests in SH2** | 2009-11-10 → 2009-07-01 (-132d) |  | 10d → 103.5d |  |  |
| 118 | Execute System Integration Tests | 2009-11-10 → 2009-07-01 (-132d) | 2009-11-17 → 2009-07-09 (-131d) |  |  | 52d → 145.5d |
| 119 | Financial Close | 2009-11-10 → 2009-07-01 (-132d) | 2009-11-10 → 2009-07-02 (-131d) |  |  | 57d → 150.5d |
| 120 | Issue Retesting | 2009-11-10 → 2009-07-01 (-132d) | 2009-11-12 → 2009-07-06 (-129d) |  |  | 55d → 148.5d |
| 125 | Issue retesting | 2009-12-05 → 2009-12-07 (+2d) |  |  |  | 149d → 36d |

## Version 6 (saved 2009-10-26)

Last finish stays 2010-01-28. Complete tasks 13 → 19.

Changed:

| ID | Task | Start | Finish | Complete | Total float |
| --- | --- | --- | --- | --- | --- |
| 1 | **2009 Support Pack Implementation Project** |  |  | 8% → 12% |  |
| 53 | **System Admin Preparation** |  |  | 5% → 79% | 74d → 0d |
| 58 | **SH3 Practice update (TBD)** | 2009-10-08 A | 2009-10-16 A | 0% → 100% | 74d → none |
| 59 | Test Install Basis Enhancement Pack 1 | 2009-10-08 A | 2009-10-16 A | 0% → 100% | 76d → none |
| 60 | Test Install Enhancement Pack 4 | 2009-10-08 A | 2009-10-16 A | 0% → 100% | 76d → none |
| 61 | Support packs available from SAP | 2009-10-15 A | 2009-10-15 A | 0% → 100% | 10d → none |
| 66 | PS1 Snapshot for SH2 | 2009-10-19 A | 2009-10-19 A | 0% → 100% | 0d → none |
| 68 | **SFK Update (Evaluation)** | 2009-10-19 A |  | 0% → 13% |  |
| 69 | Apply SAP kernel update | 2009-10-19 A | 2009-10-19 A | 0% → 100% | 68d → none |
| 70 | Upgrade Oracle db | 2009-10-19 A | 2009-10-19 A | 0% → 100% | 67.5d → none |

## Version 7 (saved 2009-10-28)

Last finish stays 2010-01-28. Complete tasks 19 → 28.

Added:

| ID | Task | Duration | Start | Finish | Predecessors | Constraint |
| --- | --- | --- | --- | --- | --- | --- |
| 138 | Apply SAP kernel update | 1d | 2009-11-05 | 2009-11-05 | 136 | finish no earlier than 2009-11-04 |
| 140 | Install Support packages, Basis Enhancement Pack 1, ERP EH 4, + Additional packages req'd for HR | 2d? | 2009-11-05 | 2009-11-06 |  | finish no earlier than 2009-11-06 |
| 142 | Apply updates for SAML authentication | 1d? | 2009-11-06 | 2009-11-06 |  | start no earlier than 2009-11-06 |
| 143 | Apply updates for SAP connect email functionality | 1d? | 2009-11-06 | 2009-11-06 |  | start no earlier than 2009-11-06 |
| 144 | Import transports from SF3 & SF2 | 0.5d | 2009-11-06 | 2009-11-06 |  | start no earlier than 2009-11-06 |
| 145 | Execute action log (add updates if necessary) | 9d | 2009-11-06 | 2009-11-18 |  | finish no earlier than 2009-11-18 |
| 147 | Apply SAP kernel update | 1d | 2009-11-19 | 2009-11-19 |  | start no earlier than 2009-11-19 |
| 148 | Upgrade Oracle db | 1d | 2009-11-19 | 2009-11-19 |  | start no earlier than 2009-11-19 |
| 149 | Install Support packages, Basis Enhancement Pack 1, ERP EH 4, + Additional packages req'd for HR | 2d? | 2009-11-20 | 2009-11-23 |  | start no earlier than 2009-11-20 |
| 150 | Apply BSI Tax Factory Update | 0.25d | 2009-11-20 | 2009-11-20 |  | start no earlier than 2009-11-20 |
| 151 | Apply updates for SAML authentication | 1d? | 2009-11-20 | 2009-11-20 |  | start no earlier than 2009-11-20 |
| 152 | Apply updates for SAP connect email functionality | 1d? | 2009-11-20 | 2009-11-20 |  | start no earlier than 2009-11-20 |
| 153 | Import transports from SF3 & SF2 | 0.5d | 2009-11-20 | 2009-11-20 |  | start no earlier than 2009-11-20 |
| 154 | Execute action log (add updates if necessary) | 7d | 2009-11-20 | 2009-11-30 |  | start no earlier than 2009-11-20 |

Removed: 50 Business owners select transactions and send back catalogs; 51 Business owners define testers and send back list to Team leads; 140 Import post snapshot production transports (delta from 10/20 to 10/30); 141 Apply kernel update; 143 Iinstall basis enhancement pack 1; 144 Install ECC enhancement pack 4; 145 Import support packages; 147 Import SF3 transports & post-update DEV transports (to be tested during SI & UAT); 148 Execute trial balance and compare with TB from 10/20; 149 Execute action log; 150 Execute DWH extracts and comparison

Changed:

| ID | Task | Start | Finish | Duration | Complete | Total float | Predecessors | Other |
| --- | --- | --- | --- | --- | --- | --- | --- | --- |
| 1 | **2009 Support Pack Implementation Project** | 2008-10-13 A → 2009-07-01 A (+261d) |  | 334d? → 152d? | 12% → 20% |  |  |  |
| 2 | **Project Prep & Planning** | 2008-10-13 A → 2009-07-01 A (+261d) | 2009-09-22 → 2009-11-27 (+66d) | 242d? → 108d? | 14% → 27% | 92d → 44d |  |  |
| 21 | **Test Planning** | 2008-10-13 → 2009-07-01 A (+261d) | 2009-08-13 → 2009-11-27 (+106d) | 213.5d? → 108d? | 0% → 36% | -16.25d → 44d |  |  |
| 48 | **User Acceptance Test Planning** | 2008-10-13 → 2009-10-28 A (+380d) | 2009-08-10 → 2009-11-27 (+109d) | 210.75d → 23d | 0% → 90% | -0.25d → 44d |  |  |
| 49 | Send test script catalog to business owners | 2009-08-10 → 2009-10-28 A (+79d) | 2009-08-10 → 2009-10-28 A (+79d) |  | 0% → 100% | -1.25d → none |  | constraint start no earlier than 2008-10-14 → start no earlier than 2009-10-28 |
| 50 | Business analysts update test script catalogs | 2008-10-27 → 2009-10-28 A (+366d) | 2008-10-28 → 2009-11-27 (+395d) | 2d → 23d | 0% → 90% | 38d → 44d | Business owners define testers and send back list to Team leads → none | constraint none → finish no earlier than 2009-11-27 |
| 51 | **System Admin Preparation** | 2009-07-01 A → 2009-09-28 A (+89d) | 2009-10-16 → 2009-11-02 (+17d) | 78d? → 26d? | 79% → 93% | 0d → 63d |  |  |
| 52 | Produce Side Effects Report | 2009-07-01 → 2009-11-02 A (+124d) | 2009-07-01 → 2009-11-02 (+124d) |  | 0% → 75% | 151d → 63d |  | was named Produce Support Package Notes; constraint none → start no earlier than 2009-11-02 |
| 53 | Review and update action log from previous year | 2009-07-01 → 2009-10-30 A (+121d) | 2009-07-02 → 2009-11-02 (+123d) |  | 0% → 50% | 150d → 63d |  | constraint none → start no earlier than 2009-10-30 |
| 54 | Upgrade Epi-use | 2009-07-01 → 2009-10-23 A (+114d) | 2009-07-01 → 2009-10-23 A (+114d) |  | 0% → 100% | 0d → none |  |  |
| 60 | **SF3 System Refresh** | 2009-07-01 A → 2009-10-08 A (+99d) | 2009-10-08 → 2009-10-09 A (+1d) | 72d → 2d | 56% → 100% | 76d → none |  |  |
| 61 | Refresh with 9/28/2009 PS1 Snapshot | 2009-07-01 A → 2009-10-08 A (+99d) | 2009-07-02 A → 2009-10-09 A (+99d) |  |  |  |  |  |
| 62 | Execute R3 Action Log | 2009-07-01 A → 2009-10-08 A (+99d) | 2009-07-01 A → 2009-10-08 A (+99d) |  |  |  |  |  |
| 63 | Scramble sensitive data | 2009-10-07 → 2009-10-08 A (+1d) | 2009-10-08 → 2009-10-09 A (+1d) |  | 0% → 100% | 44d → none |  |  |
| 65 | DW pull & store extracts | 2009-10-20 A | 2009-10-20 A |  | 0% → 100% | 0d → none |  |  |
| 66 | **SFK Update (Evaluation)** |  |  |  | 13% → 31% |  |  |  |
| 69 | Install Support packages, Basis Enhancement Pack 1, ERP EH 4, + Additional packages req'd for HR | 2009-10-20 A |  |  | 0% → 33% | 0d → 68d |  |  |
| 73 | **Zuttreq updates** | 2009-07-01 → 2009-10-23 (+114d) | 2009-10-23 → 2009-11-03 (+11d) | 83d? → 7.25d? |  | 69d → 62.75d |  |  |
| 75 | Change target system in Zuttreq | 2009-07-01 → 2009-11-03 (+125d) | 2009-07-01 → 2009-11-03 (+125d) |  |  | 151.75d → 62.75d |  | constraint none → start no earlier than 2009-11-03 |
| 76 | **SF3 Update** | 2009-10-22 A |  |  | 0% → 9% |  |  |  |
| 77 | Apply SAP kernel update | 2009-10-22 A | 2009-10-22 A |  | 0% → 100% | 68d → none |  |  |
| 78 | Upgrade Oracle db | 2009-10-23 A | 2009-10-23 A |  | 0% → 100% | 67.5d → none |  |  |
| 79 | Install Support packages, Basis Enhancement Pack 1, ERP EH 4, + Additional packages req'd for HR | 2009-10-26 A |  |  | 0% → 10% |  |  |  |
| 87 | Open enrollment transports to production | 2009-10-29 A | 2009-10-29 A |  | 0% → 100% | 0d → none |  |  |
| 88 | Netweaver/Adobe Document Server Update (Larch) | 2009-10-29 A |  |  | 0% → 50% |  |  |  |
| 89 | **SF2 Update (Development)** | 2009-10-30 A |  |  | 0% → 32% |  |  |  |
| 90 | Apply SAP kernel update | 2009-10-30 A | 2009-10-30 A |  | 0% → 100% | 59.5d → none |  |  |
| 91 | Upgrade Oracle db | 2009-10-30 A | 2009-10-30 A |  | 0% → 100% | 59.5d → none |  |  |
| 105 | **SH2 Update** | 2009-11-04 → 2009-11-03 (-1d) | 2009-11-06 → 2009-11-16 (+10d) | 3d? → 10d? |  | 59d → 53d |  |  |
| 108 | Install Support packages, Basis Enhancement Pack 1, ERP EH 4, + Additional packages req'd for HR | 2009-11-05 → 2009-11-03 (-2d) | 2009-11-06 → 2009-11-16 (+10d) | 2d? → 10d? |  | 59d → 53d |  | constraint finish no earlier than 2009-11-06 → start no earlier than 2009-11-03 |
| 114 | Compare data warehouse extracts | 2009-07-01 → 2009-11-06 (+128d) | 2009-07-01 → 2009-11-06 (+128d) |  |  | 145.5d → 53.5d |  | constraint none → start no earlier than 2009-11-06 |
| 115 | **Execute System Integration Tests in SH2** | 2009-07-01 → 2009-11-06 (+128d) |  | 103.5d → 11.5d |  |  |  |  |
| 116 | Execute System Integration Tests | 2009-07-01 → 2009-11-06 (+128d) | 2009-07-09 → 2009-11-16 (+130d) |  |  | 145.5d → 53.5d | Execute action log, 114 → 114 |  |
| 117 | Financial Close | 2009-07-01 → 2009-11-06 (+128d) | 2009-07-02 → 2009-11-09 (+130d) |  |  | 150.5d → 58.5d | Execute action log, 114 → 114 |  |
| 118 | Issue Retesting | 2009-07-01 → 2009-11-06 (+128d) | 2009-07-06 → 2009-11-11 (+128d) |  |  | 148.5d → 56.5d | Execute action log, 114 → 114 |  |
| 119 | System Integration Test sign-off |  |  |  |  |  | Execute action log, 114 → 114 |  |
| 135 | **Following dates & sequence to be confirmed** | 2009-07-01 → 2009-11-02 (+124d) |  | 152d? → 64d? |  |  |  |  |
| 137 | **SF6 Update** | 2009-07-01 → 2009-11-05 (+127d) | 2009-07-01 → 2009-11-18 (+140d) | 1d? → 10d? |  | 145.5d → 51d |  |  |
| 139 | Upgrade Oracle db | 2009-07-01 → 2009-11-05 (+127d) | 2009-07-01 → 2009-11-05 (+127d) | 0.5d → 1d |  | 151.5d → 60d |  | constraint none → start no earlier than 2009-11-05 |
| 141 | Apply BSI Tax Factory Update | 2009-07-01 → 2009-11-05 (+127d) | 2009-07-01 → 2009-11-05 (+127d) |  |  | 151.75d → 60.75d |  | constraint none → start no earlier than 2009-11-05 |
| 146 | **SF7 Update** | 2009-12-01 → 2009-11-19 (-12d) | 2009-12-01 → 2009-11-30 (-1d) | 1d? → 8d? |  | 42d → 43d |  | constraint start no earlier than 2009-12-01 → none |

## Version 8 (saved 2009-10-29)

Last finish stays 2010-01-28.

Changed:

| ID | Task | Start | Duration | Other |
| --- | --- | --- | --- | --- |
| 122 | Financial Close | 2009-12-04 → 2009-12-03 (-1d) | 1d → 2d | constraint finish no earlier than 2009-12-04 → start no earlier than 2009-12-03 |

## Version 9 (saved 2009-12-03)

Last finish stays 2010-01-28. Complete tasks 28 → 67.

Added:

| ID | Task | Duration | Start | Finish | Constraint |
| --- | --- | --- | --- | --- | --- |
| 124 | **Execute pre-update validation testing in SH1** | 3d | 2009-12-02 | 2009-12-04 |  |
| 125 | Execute validation test | 3d | 2009-12-02 | 2009-12-04 | start no earlier than 2009-12-02 |

Changed:

| ID | Task | Start | Finish | Duration | Complete | Total float | Predecessors | Other |
| --- | --- | --- | --- | --- | --- | --- | --- | --- |
| 1 | **2009 Support Pack Implementation Project** |  |  |  | 20% → 38% |  |  |  |
| 66 | **SFK Update (Evaluation)** |  | 2009-10-26 A |  | 31% → 100% | 68d → none |  |  |
| 69 | Install Support packages, Basis Enhancement Pack 1, ERP EH 4, + Additional packages req'd for HR |  | 2009-10-23 A |  | 33% → 100% | 68d → none |  |  |
| 70 | Validate security infrastructure (SNC) | 2009-10-26 A | 2009-10-26 A |  | 0% → 100% | 68d → none |  |  |
| 71 | Validate SAPGui interactions | 2009-10-26 A | 2009-10-26 A |  | 0% → 100% | 68.5d → none |  |  |
| 72 | Validate basic SAP functions work | 2009-10-26 A | 2009-10-26 A |  | 0% → 100% | 68d → none |  |  |
| 73 | **Zuttreq updates** | 2009-10-23 A | 2009-11-03 A |  | 0% → 100% | 62.75d → none |  |  |
| 74 | Change target system for transport layer | 2009-10-23 A | 2009-10-23 A |  | 0% → 100% | 69d → none |  |  |
| 75 | Change target system in Zuttreq | 2009-11-03 A | 2009-11-03 A |  | 0% → 100% | 62.75d → none |  |  |
| 76 | **SF3 Update** |  | 2009-11-03 A |  | 9% → 100% | 62d → none |  |  |
| 79 | Install Support packages, Basis Enhancement Pack 1, ERP EH 4, + Additional packages req'd for HR |  | 2009-10-28 A |  | 10% → 100% | 66d → none |  |  |
| 80 | Update BSI | 2009-10-26 A | 2009-10-28 A |  | 0% → 100% | 66d → none |  |  |
| 81 | SPAU, OSS notes | 2009-10-29 A | 2009-10-30 A |  | 0% → 100% | 63d → none |  |  |
| 82 | Check, decide, apply MIT mods or use enhancement framework | 2009-10-30 A | 2009-11-02 A |  | 0% → 100% | 63d → none |  |  |
| 83 | SAP developer functionality validation | 2009-10-29 A | 2009-10-29 A |  | 0% → 100% | 65d → none |  |  |
| 84 | Apply updates for SAML authentication | 2009-11-02 A | 2009-11-02 A |  | 0% → 100% | 63d → none |  |  |
| 85 | Apply updates for SAP connect email functionality | 2009-11-03 A | 2009-11-03 A |  | 0% → 100% | 62d → none |  |  |
| 86 | Validate - external interfaces ITS, jco, mitid, fax. | 2009-11-03 A | 2009-11-03 A |  | 0% → 100% | 62d → none |  |  |
| 88 | Netweaver/Adobe Document Server Update (Larch) |  | 2009-10-30 A |  | 50% → 100% | 64d → none |  |  |
| 89 | **SF2 Update (Development)** |  | 2009-11-02 A |  | 32% → 100% | 58.5d → none |  |  |
| 92 | Install Support packages, Basis Enhancement Pack 1, ERP EH 4, + Additional packages req'd for HR | 2009-10-30 A | 2009-11-01 A |  | 0% → 100% | 59.5d → none |  |  |
| 93 | Apply updates for SAML authentication | 2009-11-02 A | 2009-11-02 A |  | 0% → 100% | 58.5d → none |  |  |
| 94 | Apply updates for SAP connect email functionality | 2009-11-02 A | 2009-11-02 A |  | 0% → 100% | 58.5d → none |  |  |
| 95 | Import transports from SF3 | 2009-11-02 A | 2009-11-02 A |  | 0% → 100% | 59d → none |  |  |
| 96 | Apply BSI Tax Factory Update | 2009-11-02 A | 2009-11-02 A |  | 0% → 100% | 59.25d → none |  |  |
| 97 | Execute action log (add updates if necessary) | 2009-11-02 A | 2009-11-02 A |  | 0% → 100% | 59d → none |  |  |
| 98 | **Unit Test Execution in SF2** | 2009-11-03 → 2009-11-05 A (+2d) | 2009-11-09 → 2009-11-10 A (+1d) | 4.5d → 4d | 0% → 100% | 58.5d → none |  |  |
| 99 | Financial Unit Tests, Issue identification and retest | 2009-11-03 → 2009-11-05 A (+2d) | 2009-11-09 A | 4.5d → 3d | 0% → 100% | 58.5d → none |  |  |
| 100 | Logistics Unit Tests, Issue identification and retest | 2009-11-03 → 2009-11-05 A (+2d) | 2009-11-09 A | 4.5d → 3d | 0% → 100% | 58.5d → none |  |  |
| 101 | EHS Unit Tests, Issue identification and retest | 2009-11-03 → 2009-11-05 A (+2d) | 2009-11-09 A | 4.5d → 3d | 0% → 100% | 58.5d → none |  |  |
| 102 | HR-Payroll Unit Tests, Issue identification and retest | 2009-11-03 → 2009-11-05 A (+2d) | 2009-11-09 A | 4.5d → 3d | 0% → 100% | 58.5d → none |  |  |
| 103 | All functional teams ok environment and move to SIT | 2009-11-08 → 2009-11-09 A (+1d) | 2009-11-08 → 2009-11-10 A (+2d) | 0d → 2d | 0% → 100% | 59d → none |  |  |
| 104 | SH2 System Refresh | 2009-10-26 A | 2009-10-30 A |  | 0% → 100% | 64d → none |  |  |
| 105 | **SH2 Update** | 2009-11-03 A | 2009-11-16 A |  | 0% → 100% | 53d → none |  |  |
| 106 | Apply SAP kernel update | 2009-11-04 A | 2009-11-04 A |  | 0% → 100% | 61d → none |  |  |
| 107 | Upgrade Oracle db | 2009-11-04 A | 2009-11-04 A |  | 0% → 100% | 61d → none |  |  |
| 108 | Install Support packages, Basis Enhancement Pack 1, ERP EH 4, + Additional packages req'd for HR | 2009-11-03 A | 2009-11-16 A |  | 0% → 100% | 53d → none |  |  |
| 109 | Apply BSI Tax Factory Update | 2009-11-05 A | 2009-11-05 A |  | 0% → 100% | 60.75d → none |  |  |
| 110 | Apply updates for SAML authentication | 2009-11-06 A | 2009-11-06 A |  | 0% → 100% | 59d → none |  |  |
| 111 | Apply updates for SAP connect email functionality | 2009-11-06 A | 2009-11-06 A |  | 0% → 100% | 59d → none |  |  |
| 112 | Import transports from SF3 & SF2 | 2009-11-06 A | 2009-11-06 A |  | 0% → 100% | 59.5d → none |  |  |
| 113 | Execute action log (add updates if necessary) | 2009-11-06 A | 2009-11-06 A |  | 0% → 100% | 59.5d → none |  |  |
| 114 | Compare data warehouse extracts | 2009-11-06 A | 2009-11-06 A |  | 0% → 100% | 53.5d → none |  |  |
| 115 | **Execute System Integration Tests in SH2** | 2009-11-06 → 2009-11-13 A (+7d) | 2009-11-23 → 2009-11-25 (+2d) | 11.5d → 9d | 0% → 92% | 48d → 46d |  |  |
| 116 | Execute System Integration Tests | 2009-11-06 → 2009-11-13 A (+7d) | 2009-11-16 → 2009-11-20 A (+4d) |  | 0% → 100% | 53.5d → none |  |  |
| 117 | Financial Close | 2009-11-06 → 2009-11-13 A (+7d) | 2009-11-09 → 2009-11-13 A (+4d) |  | 0% → 100% | 58.5d → none |  |  |
| 118 | Issue Retesting | 2009-11-06 → 2009-11-19 A (+13d) | 2009-11-11 → 2009-11-24 A (+13d) | 3d → 4d | 0% → 100% | 56.5d → none |  |  |
| 119 | System Integration Test sign-off | 2009-11-23 → 2009-11-25 (+2d) | 2009-11-23 → 2009-11-25 (+2d) |  |  | 48d → 46d |  | constraint finish no earlier than 2009-11-23 → start no earlier than 2009-11-25 |
| 120 | **Execute User Acceptance Test (UAT) in SH2** | 2009-11-24 → 2009-11-13 (-11d) |  | 12d → 19d |  |  |  |  |
| 121 | Execute UAT | 2009-11-24 → 2009-11-13 (-11d) | 2009-12-04 → 2009-12-07 (+3d) | 9d → 17d |  | 39d → 36d |  | constraint finish no earlier than 2009-12-04 → finish no earlier than 2009-12-07 |
| 122 | Financial Close | 2009-12-03 → 2009-12-08 (+5d) | 2009-12-04 → 2009-12-09 (+5d) |  |  | 39d → 36d | none → 121 | constraint start no earlier than 2009-12-03 → none |
| 123 | Issue retesting | 2009-12-07 → 2009-12-03 (-4d) |  | 3d → 5d |  |  |  | constraint start no earlier than 2009-12-05 → start no earlier than 2009-12-03 |
| 126 | validation test sign off | 2009-12-10 → 2009-12-04 (-6d) | 2009-12-10 → 2009-12-04 (-6d) |  |  | 34d → 38d |  | was named UAT sign off; constraint start no earlier than 2009-12-10 → start no earlier than 2009-12-04 |
| 127 | **Cutover weekend & Controlled Start** | 2009-12-10 → 2009-12-04 (-6d) |  | 2d? → 6d? |  |  |  |  |
| 128 | Netweaver/Adobe Document Server Update (Snowbell) | 2009-12-11 → 2009-12-07 (-4d) | 2009-12-11 → 2009-12-07 (-4d) |  |  | 34d → 38d |  |  |
| 129 | System message put out on SAP | 2009-12-11 → 2009-12-07 (-4d) | 2009-12-11 → 2009-12-07 (-4d) |  |  | 34.75d → 38.75d |  |  |
| 130 | System message put out on SAPWeb pages | 2009-12-11 → 2009-12-07 (-4d) | 2009-12-11 → 2009-12-07 (-4d) |  |  | 34.75d → 38.75d |  |  |
| 131 | Update production (detailed weekend cutover plan in a separate document) | 2009-12-11 → 2009-12-07 (-4d) | 2009-12-11 → 2009-12-07 (-4d) |  |  | 34d → 38d |  |  |
| 132 | Production validation | 2009-12-10 → 2009-12-04 (-6d) | 2009-12-10 → 2009-12-04 (-6d) |  |  | 35d → 39d |  |  |
| 133 | Go/No Go approval | 2009-12-10 → 2009-12-04 (-6d) | 2009-12-10 → 2009-12-04 (-6d) |  |  | 35d → 39d |  |  |
